# Planning ecoparque 2

Schedule from MS Project, 2004-11-01 to 2007-10-05.
Steinmüller Valorga

## Calendars

- Standard: Mon-Fri 08:00-12:00, 13:00-17:00; Sat-Sun off.

## Schedule

| ID | WBS | Task | Type | Duration | Start | Finish | Predecessors | Total slack | Free slack | Constraint |
| --- | --- | --- | --- | --- | --- | --- | --- | --- | --- | --- |
| 1 | 1 | Notification du contrat | milestone | 0w | 2004-11-01 | 2004-11-01 |  | 0d |  | start no earlier than 2004-11-01 |
| 2 | 2 | **Phase 1** |  | 45d | 2004-11-01 | 2004-12-31 |  | 0d |  |  |
| 3 | 2.1 | Etudes pour Dossier d'Autorisation d'Exploiter (DAE) et Permis de Construire (PC) |  | 9w | 2004-11-01 | 2004-12-31 | 1 | 0d |  | start no earlier than 2001-05-14 |
| 4 | 2.2 | Dépôt DAE et PC | milestone | 0w | 2004-12-31 | 2004-12-31 | 3 | 0d |  | start no earlier than 2001-05-14 |
| 5 | 3 | **Phase 2** |  | 130d | 2005-01-03 | 2005-07-01 | 4 | 0d |  |  |
| 6 | 3.1 | Délai entre dépôt DAE/PC et notification de l'autorisation |  | 26w | 2005-01-03 | 2005-07-01 | 4 | 0d |  |  |
| 7 | 4 | Etudes de base |  | 9w | 2004-11-01 | 2004-12-31 | 3SS | 590d | 0d |  |
| 8 | 5 | Etudes d'exécution |  | 26w | 2005-01-03 | 2005-07-01 | 7 | 590d |  |  |
| 9 | 6 | Ordre de service n°2 | milestone | 0w | 2005-07-01 | 2005-07-01 | 6 | 0d |  |  |
| 10 | 7 | **Phase 3** |  | 590d | 2005-07-04 | 2007-10-05 |  | 0d |  |  |
| 11 | 7.1 | Etudes de détails |  | 59w | 2005-07-04 | 2006-08-18 | 9 | 295d |  |  |
| 12 | 7.2 | **Travaux génie civil & process** |  | 325d | 2005-07-04 | 2006-09-29 |  | 0d |  |  |
| 13 | 7.2.1 | Préparation du terrain |  | 5w | 2005-07-04 | 2005-08-05 | 9 | 0d |  |  |
| 15 | 7.2.2 | **BÂTIMENT METHANISATION & FFOM** |  | 300d | 2005-08-08 | 2006-09-29 |  | 0d |  |  |
| 16 | 7.2.2.1 | Fondation/Terrassement/Massifs/Gros oeuvre |  | 18w | 2005-08-08 | 2005-12-09 | 13 | 0d |  |  |
| 17 | 7.2.2.2 | Charpente métallique |  | 6w | 2005-12-12 | 2006-01-20 | 16 | 0d |  |  |
| 18 | 7.2.2.3 | Livraison/montage des équipements lourds |  | 4w | 2005-12-26 | 2006-01-20 | 17SS+2w | 225d |  | start no earlier than 2005-02-14 |
| 19 | 7.2.2.4 | Couverture/Dalle |  | 4w | 2006-01-23 | 2006-02-17 | 17 | 0d |  |  |
| 20 | 7.2.2.5 | Livraison/montage des équipements annexes |  | 7w | 2006-02-06 | 2006-03-24 | 19SS+2w | 0d |  |  |
| 21 | 7.2.2.6 | Bardage/Finition |  | 9w | 2006-02-06 | 2006-04-07 | 19SS+2w | 170d |  |  |
| 22 | 7.2.2.7 | Tuyauterie équipements |  | 12w | 2006-03-27 | 2006-06-16 | 20 | 0d |  |  |
| 23 | 7.2.2.8 | Electricité |  | 12w | 2006-05-22 | 2006-08-11 | 22SS+8w | 0d |  |  |
| 24 | 7.2.2.9 | Instrumentation et automatismes |  | 12w | 2006-07-10 | 2006-09-29 | 23SS+7w | 0d |  |  |
| 25 | 7.2.2.10 | Tuyauterie digesteurs |  | 15w | 2006-05-15 | 2006-08-25 |  | 70d |  | start no earlier than 2006-05-15 |

| ID | WBS | Task | Type | Duration | Start | Finish | Predecessors | Total slack | Free slack | Constraint |
| --- | --- | --- | --- | --- | --- | --- | --- | --- | --- | --- |
| 27 | 7.2.3 | **BÂTIMENT MATURATION/AFFINAGE/STOCKAGE** |  | 280d | 2005-08-08 | 2006-09-01 |  | 285d |  |  |
| 28 | 7.2.3.1 | Fondation/Terrassement/Massifs/Gros oeuvre |  | 30w | 2005-08-08 | 2006-03-03 | 13 | 195d |  |  |
| 29 | 7.2.3.2 | Charpente métallique |  | 13w | 2005-12-12 | 2006-03-10 | 17SS | 65d | 0d |  |
| 30 | 7.2.3.3 | Livraison/montage des équipements lourds |  | 4w | 2006-01-09 | 2006-02-03 | 29SS+4w | 185d | 0d | start no earlier than 2005-02-14 |
| 31 | 7.2.3.4 | Couverture/Dalle |  | 15w | 2006-01-09 | 2006-04-21 | 29SS+4w | 65d | 0d |  |
| 32 | 7.2.3.5 | Livraison/montage des équipements annexes |  | 6w | 2006-02-06 | 2006-03-17 | 30 | 185d |  |  |
| 33 | 7.2.3.6 | Bardage/Finition |  | 7w | 2006-04-10 | 2006-05-26 | 31SS+13w | 65d | 0d |  |
| 34 | 7.2.3.7 | Electricité |  | 8w | 2006-05-29 | 2006-07-21 | 33 | 65d | 0d |  |
| 35 | 7.2.3.8 | Instrumentation et automatismes |  | 6w | 2006-07-24 | 2006-09-01 | 34 | 65d |  |  |
| 37 | 7.2.4 | **BÂTIMENT BIOGAZ** |  | 290d | 2005-08-08 | 2006-09-15 |  | 275d |  |  |
| 38 | 7.2.4.1 | Fondation/Terrassement/Massifs/Gros oeuvre |  | 12w | 2005-08-08 | 2005-10-28 | 13 | 285d |  |  |
| 39 | 7.2.4.2 | Local béton |  | 10w | 2005-12-12 | 2006-02-17 | 17SS | 70d | 0d |  |
| 40 | 7.2.4.3 | Livraison/montage des équipements lourds |  | 4w | 2006-01-09 | 2006-02-03 | 39SS+4w | 70d | 0d | start no earlier than 2005-02-14 |
| 41 | 7.2.4.4 | Couverture/Dalle |  | 8w | 2006-02-06 | 2006-03-31 | 40 | 175d |  |  |
| 42 | 7.2.4.5 | Livraison/montage des équipements annexes |  | 5w | 2006-02-06 | 2006-03-10 | 40 | 70d | 0d |  |
| 43 | 7.2.4.6 | Bardage/Finition |  | 4w | 2006-03-13 | 2006-04-07 | 42 | 170d |  |  |
| 44 | 7.2.4.7 | Tuyauterie équipements |  | 14w | 2006-03-13 | 2006-06-16 | 42 | 70d | 0d |  |
| 45 | 7.2.4.8 | Electricité |  | 12w | 2006-05-29 | 2006-08-18 | 44SS+11w | 275d | 0d |  |
| 46 | 7.2.4.9 | Instrumentation et automatismes |  | 8w | 2006-07-24 | 2006-09-15 | 45SS+8w | 275d |  |  |
| 48 | 7.2.5 | **DIGESTEURS** |  | 135d | 2005-08-08 | 2006-02-10 |  | 430d |  |  |
| 49 | 7.2.5.1 | **Digesteur OMR n°1** |  | 115d | 2005-08-08 | 2006-01-13 |  | 435d |  |  |
| 50 | 7.2.5.1.1 | Radier+voile+dalle digesteur OMR n°1 |  | 6w | 2005-08-08 | 2005-09-16 | 13 | 390d | 0d |  |
| 51 | 7.2.5.1.2 | Glissant + démontage digesteur OMR n°1 |  | 2w | 2005-09-19 | 2005-09-30 | 50 | 390d | 0d |  |
| 52 | 7.2.5.1.3 | Précontrainte + toiture digesteur OMR n°1 |  | 8w | 2005-10-03 | 2005-11-25 | 51 | 390d | 0d |  |
| 53 | 7.2.5.1.4 | Mise en eau, vidange digesteur OMR n°1 |  | 3w | 2005-11-28 | 2005-12-16 | 52 | 390d | 0d | finish no earlier than 2003-02-28 |
| 54 | 7.2.5.1.5 | Fin essai en eau digesteur OMR n°1 | milestone | 0w | 2005-12-16 | 2005-12-16 | 53 | 405d | 0d |  |
| 55 | 7.2.5.1.6 | Bardage digesteur OMR n°1 |  | 3w | 2005-12-12 | 2005-12-30 | 54FS-1w | 405d | 0d |  |
| 56 | 7.2.5.1.7 | Etanchéité toiture digesteur OMR n°1 |  | 1w | 2006-01-02 | 2006-01-06 | 55 | 405d | 0d | finish no earlier than 2003-03-14 |
| 57 | 7.2.5.1.8 | Finitions digesteur OMR n°1 |  | 1w | 2006-01-09 | 2006-01-13 | 56 | 405d |  |  |

| ID | WBS | Task | Type | Duration | Start | Finish | Predecessors | Total slack | Free slack | Constraint |
| --- | --- | --- | --- | --- | --- | --- | --- | --- | --- | --- |
| 58 | 7.2.5.2 | **Digesteur OMR n°2** |  | 120d | 2005-08-29 | 2006-02-10 |  | 430d |  |  |
| 59 | 7.2.5.2.1 | Radier+voile+dalle digesteur OMR n°2 |  | 6w | 2005-08-29 | 2005-10-07 |  | 390d | 0d | start no earlier than 2005-08-29 |
| 60 | 7.2.5.2.2 | Glissant + démontage digesteur OMR n°2 |  | 2w | 2005-10-10 | 2005-10-21 | 51, 59 | 390d | 0d | start no earlier than 2005-10-10 |
| 61 | 7.2.5.2.3 | Précontrainte + toiture digesteur OMR n°2 |  | 8w | 2005-10-24 | 2005-12-16 | 60 | 390d | 0d |  |
| 62 | 7.2.5.2.4 | Mise en eau, vidange digesteur OMR n°2 |  | 3w | 2005-12-19 | 2006-01-06 | 61, 53 | 390d | 5d | finish no earlier than 2003-02-28 |
| 63 | 7.2.5.2.5 | Fin essai en eau digesteur OMR n°2 | milestone | 0w | 2006-01-16 | 2006-01-16 | 62 | 385d | 0d | start no earlier than 2006-01-16 |
| 64 | 7.2.5.2.6 | Bardage digesteur OMR n°2 |  | 3w | 2006-01-09 | 2006-01-27 | 63FS-1w | 385d | 0d |  |
| 65 | 7.2.5.2.7 | Etanchéité toiture digesteur OMR n°2 |  | 1w | 2006-01-30 | 2006-02-03 | 64 | 385d | 0d | finish no earlier than 2003-03-14 |
| 66 | 7.2.5.2.8 | Finitions digesteur OMR n°2 |  | 1w | 2006-02-06 | 2006-02-10 | 65 | 385d |  |  |
| 68 | 7.3 | Constat d'Achévement des Travaux | milestone | 0w | 2006-09-29 | 2006-09-29 | 24 | 0d |  |  |
| 69 | 7.4 | Essais a vide |  | 9w | 2006-10-02 | 2006-12-01 | 68 | 0d |  |  |
| 70 | 7.5 | Réception mécanique | milestone | 0w | 2006-12-01 | 2006-12-01 | 69 | 0d |  |  |
| 71 | 7.6 | Préparation biologique aérobie |  | 13w | 2006-12-04 | 2007-03-02 | 70 | 0d |  |  |
| 72 | 7.7 | Mise en régime biologique anaérobie |  | 26w | 2007-02-05 | 2007-08-03 | 71FS-4w | 0d |  |  |
| 73 | 7.8 | Réception biologique | milestone | 0w | 2007-08-03 | 2007-08-03 | 72 | 0d |  |  |
| 74 | 7.9 | Mise en Service Industrielle (MSI) |  | 9w | 2007-08-06 | 2007-10-05 | 73 | 0d |  |  |
| 75 | 7.10 | Fin de MSI | milestone | 0w | 2007-10-05 | 2007-10-05 | 74 | 0d |  |  |
